# Civil Work Project

Schedule from MS Project, 2025-12-23 to 2026-05-18, costs in ₹.

## Calendars

- Standard: Mon-Fri 08:00-12:00, 13:00-17:00; Sat-Sun off.

## Resources

| Resource | Rate |
| --- | --- |
| Surveyor | 1550 |
| Geotechnical Engineer | 2000 |
| Excavation Crew | 300 |
| Excavator | 400 |
| Labor | 100 |
| Mason | 1000 |
| Bar Bender | 100 |
| Carpenter | 200 |
| Concrete Gang | 300 |
| Plastering Crew | 100 |

## Schedule

| ID | WBS | Task | Duration | Start | Finish | Predecessors | Total slack | Resources | Work | Cost |
| --- | --- | --- | --- | --- | --- | --- | --- | --- | --- | --- |
| 1 | 1 | **Civil Work Project** | 16d | 2025-12-23 | 2026-01-13 |  | 0d |  | 128h | 172,800 |
| 2 | 1.1 | Site Survey & Investigation | 5d | 2025-12-23 | 2025-12-29 |  | 0d | Surveyor | 40h | 62,000 |
| 3 | 1.2 | Soil Testing | 4d | 2025-12-30 | 2026-01-02 | 2 | 0d | Geotechnical Engineer | 32h | 64,000 |
| 4 | 1.3 | Layout Marking | 3d | 2026-01-05 | 2026-01-07 | 3 | 0d | Surveyor | 24h | 37,200 |
| 5 | 1.4 | Site Clearance | 4d | 2026-01-08 | 2026-01-13 | 4 | 0d | Excavation Crew | 32h | 9,600 |
| 6 | 2 | **Earthwork & Foundation** | 27d | 2026-01-14 | 2026-02-19 |  | 0d |  | 288h | 71,200 |
| 7 | 2.1 | Excavation for Foundation | 6d | 2026-01-14 | 2026-01-21 | 5 | 0d | Excavator; Labor | 96h | 24,000 |
| 8 | 2.2 | PCC (Plain Cement Concrete) | 3d | 2026-01-22 | 2026-01-26 | 7 | 0d | Mason; Labor | 48h | 26,400 |
| 9 | 2.3 | Footing Reinforcement Work | 5d | 2026-01-27 | 2026-02-02 | 8 | 0d | Bar Bender | 40h | 4,000 |
| 10 | 2.4 | Footing Shuttering | 4d | 2026-02-03 | 2026-02-06 | 9 | 0d | Carpenter | 32h | 6,400 |
| 11 | 2.5 | Footing Concrete Pouring | 2d | 2026-02-09 | 2026-02-10 | 10 | 0d | Concrete Gang | 16h | 4,800 |
| 12 | 2.6 | Curing of Footing | 7d | 2026-02-11 | 2026-02-19 | 11 | 0d | Labor | 56h | 5,600 |
| 13 | 3 | **Substructure Work** | 15d | 2026-02-20 | 2026-03-12 |  | 0d |  | 120h | 18,400 |
| 14 | 3.1 | Column Starter Reinforcement | 4d | 2026-02-20 | 2026-02-25 | 12 | 0d | Bar Bender | 32h | 3,200 |
| 15 | 3.2 | Column Shuttering | 4d | 2026-02-26 | 2026-03-03 | 14 | 0d | Carpenter | 32h | 6,400 |
| 16 | 3.3 | Column Concreting | 2d | 2026-03-04 | 2026-03-05 | 15 | 0d | Concrete Gang | 16h | 4,800 |
| 17 | 3.4 | Backfilling | 5d | 2026-03-06 | 2026-03-12 | 16 | 0d | Labor | 40h | 4,000 |
| 18 | 4 | **Superstructure Work** | 17d | 2026-03-13 | 2026-04-06 |  | 0d |  | 256h | 38,400 |
| 19 | 4.1 | Plinth Beam Reinforcement | 4d | 2026-03-13 | 2026-03-18 | 17 | 0d | Bar Bender | 32h | 3,200 |
| 20 | 4.2 | Plinth Beam Shuttering | 3d | 2026-03-19 | 2026-03-23 | 19 | 0d | Carpenter | 24h | 4,800 |
| 21 | 4.3 | Plinth Beam Concreting | 2d | 2026-03-24 | 2026-03-25 | 20 | 38d | Concrete Gang | 16h | 4,800 |
| 22 | 4.4 | Slab Reinforcement | 6d | 2026-03-19 | 2026-03-26 | 19 | 37d | Bar Bender | 48h | 4,800 |
| 23 | 4.5 | Slab Shuttering | 5d | 2026-03-24 | 2026-03-30 | 20 | 35d | Carpenter | 40h | 8,000 |
| 24 | 4.6 | Slab Concreting | 2d | 2026-03-19 | 2026-03-20 | 19 | 41d | Concrete Gang | 16h | 4,800 |
| 25 | 4.7 | Slab Curing | 10d | 2026-03-24 | 2026-04-06 | 20 | 0d | Labor | 80h | 8,000 |

| ID | WBS | Task | Type | Duration | Start | Finish | Predecessors | Total slack | Resources | Work | Cost |
| --- | --- | --- | --- | --- | --- | --- | --- | --- | --- | --- | --- |
| 26 | 5 | **Masonry & Finishing (Civil Scope)** |  | 30d | 2026-04-07 | 2026-05-18 |  | 0d |  | 240h | 132,000 |
| 27 | 5.1 | Brickwork / Blockwork |  | 10d | 2026-04-07 | 2026-04-20 | 25 | 0d | Mason | 80h | 80,000 |
| 28 | 5.2 | Internal Plaster |  | 8d | 2026-04-21 | 2026-04-30 | 27 | 0d | Plastering Crew | 64h | 6,400 |
| 29 | 5.3 | External Plaster |  | 7d | 2026-05-01 | 2026-05-11 | 28 | 0d | Plastering Crew | 56h | 5,600 |
| 30 | 5.4 | Floor Screeding |  | 5d | 2026-05-12 | 2026-05-18 | 29 | 0d | Mason | 40h | 40,000 |
| 31 | 5.5 | Civil Work Complete | milestone | 0d | 2026-05-18 | 2026-05-18 | 21, 22, 24, 25, 30, 23 | 0d |  |  |  |
