# Electrical Work Project

Schedule from MS Project, 2025-12-23 to 2026-03-03, costs in ₹.

## Calendars

- Standard: Mon-Fri 08:00-12:00, 13:00-17:00; Sat-Sun off.

## Resources

| Resource | Rate |
| --- | --- |
| Electrical Engineer | 1000 |
| Project Manager | 2000 |
| Procurement Team | 2000 |
| Store Incharge | 100 |
| Electrician | 100 |
| Electrician Team | 500 |
| Technician Team | 500 |
| Panel Technician | 200 |
| Senior Electrician | 300 |
| Electrical Technician | 200 |
| Testing Engineer | 100 |

## Schedule

| ID | WBS | Task | Type | Duration | Start | Finish | Predecessors | Total slack | Resources | Work | Cost |
| --- | --- | --- | --- | --- | --- | --- | --- | --- | --- | --- | --- |
| 1 | 1 | Electrical Work Start | milestone | 0d | 2025-12-23 | 2025-12-23 |  | 0d |  |  |  |
| 2 | 2 | **Planning & Design** |  | 5d | 2025-12-23 | 2025-12-29 |  | 0d |  | 48h | 56,000 |
| 3 | 2.1 | Review Electrical Drawings |  | 2d | 2025-12-23 | 2025-12-24 | 1 | 0d | Electrical Engineer | 16h | 16,000 |
| 4 | 2.2 | Load Calculation |  | 2d | 2025-12-25 | 2025-12-26 | 3 | 0d | Electrical Engineer | 16h | 16,000 |
| 5 | 2.3 | Client Approval |  | 1d | 2025-12-29 | 2025-12-29 | 4 | 0d | Electrical Engineer; Project Manager | 16h | 24,000 |
| 6 | 3 | **Material Procurement** |  | 8d | 2025-12-30 | 2026-01-08 |  | 0d |  | 64h | 66,400 |
| 7 | 3.1 | Prepare BOQ |  | 2d | 2025-12-30 | 2025-12-31 | 5 | 0d | Electrical Engineer | 16h | 16,000 |
| 8 | 3.2 | Vendor Finalization |  | 3d | 2026-01-01 | 2026-01-05 | 7 | 0d | Procurement Team | 24h | 48,000 |
| 9 | 3.3 | Material Delivery |  | 3d | 2026-01-06 | 2026-01-08 | 8 | 0d | Store Incharge | 24h | 2,400 |
| 10 | 4 | **Conduit & Cable Tray Work** |  | 6d | 2026-01-09 | 2026-01-16 |  | 0d |  | 80h | 33,600 |
| 11 | 4.1 | Marking & Layout |  | 2d | 2026-01-09 | 2026-01-12 | 9 | 0d | Electrician | 16h | 1,600 |
| 12 | 4.2 | Conduit Laying |  | 4d | 2026-01-13 | 2026-01-16 | 11 | 5d | Electrician Team | 32h | 16,000 |
| 13 | 4.3 | Cable Tray Installation |  | 4d | 2026-01-13 | 2026-01-16 | 11 | 0d | Technician Team | 32h | 16,000 |
| 14 | 5 | **Wiring & Panel Installation** |  | 15d | 2026-01-19 | 2026-02-06 |  | 0d |  | 120h | 40,800 |
| 15 | 5.1 | Cable Pulling |  | 5d | 2026-01-19 | 2026-01-23 | 13 | 0d | Electrician Team | 40h | 20,000 |
| 16 | 5.2 | Panel Installation |  | 4d | 2026-01-26 | 2026-01-29 | 15, 12 | 0d | Panel Technician | 32h | 6,400 |
| 17 | 5.3 | Termination & Dressing |  | 6d | 2026-01-30 | 2026-02-06 | 16 | 0d | Senior Electrician | 48h | 14,400 |
| 18 | 6 | **Fixtures & Equipment Installation** |  | 10d | 2026-02-09 | 2026-02-20 |  | 0d |  | 80h | 10,400 |
| 19 | 6.1 | Lighting Fixture Installation |  | 4d | 2026-02-09 | 2026-02-12 | 17 | 0d | Electrician | 32h | 3,200 |
| 20 | 6.2 | Switch & Socket Installation |  | 3d | 2026-02-13 | 2026-02-17 | 19 | 0d | Electrician | 24h | 2,400 |
| 21 | 6.3 | Earthing System Installation |  | 3d | 2026-02-18 | 2026-02-20 | 20 | 0d | Electrical Technician | 24h | 4,800 |
| 22 | 7 | **Testing & Commissioning** |  | 7d | 2026-02-23 | 2026-03-03 |  | 0d |  | 56h | 57,600 |
| 23 | 7.1 | Insulation Resistance Test |  | 2d | 2026-02-23 | 2026-02-24 | 21 | 0d | Testing Engineer | 16h | 1,600 |
| 24 | 7.2 | Power On & Load Test |  | 3d | 2026-02-25 | 2026-02-27 | 23 | 0d | Electrical Engineer | 24h | 24,000 |
| 25 | 7.3 | Final Inspection & Handover |  | 2d | 2026-03-02 | 2026-03-03 | 24 | 0d | Project Manager | 16h | 32,000 |
| 26 | 7.4 | End Of Electrical Work | milestone | 0d | 2026-03-03 | 2026-03-03 | 25 | 0d |  |  |  |
